# RHEA

Schedule from MS Project, 2012-05-22 to 2013-01-14, A marks actual dates.
0

## Calendars

- Standard: Mon-Fri 08:00-12:00, 13:00-17:00; Sat-Sun off.

## Resources

| Resource |
| --- |
| Apelon Inc |
| Carl Fourie |
| Chris Seebregts |
| Desire Ruzigana |
| Emmanuel Rugomboka |
| Hannes Venter |
| InSTEDD |
| Intrahealth |
| Ishimwe Ngezahayo |
| Jonnea Smith |
| Linda Taylor |
| Liz Peloso |
| Michel Makolo |
| MoH OpenMRS team |
| Pivot Access |
| Regenstrief Institute |
| Rhonwyn Cornell |
| Richard Gakuba |
| Ryan Crichton |
| Suranga Kasthurirathne |
| Sysnet |
| Wayne Naidoo |

## Schedule

| ID | WBS | Task | Duration | Start | Finish | Predecessors | Complete | Remaining | Total slack | Constraint | Resources | Work | Actual work |
| --- | --- | --- | --- | --- | --- | --- | --- | --- | --- | --- | --- | --- | --- |
| 1 | 1 | **Project management** | 93d | 2012-05-22 A | 2012-09-27 |  | 64% | 33.44d | 76.71d |  |  | 1860.4h | 1198h |
| 2 | 1.1 | Day to day project management | 4mo | 2012-05-22 A | 2012-09-10 |  | 70% | 1.2mo | 89.71d |  | Carl Fourie [15%]; Rhonwyn Cornell | 736h | 515.2h |
| 3 | 1.2 | Day to day technical management | 4mo | 2012-05-22 A | 2012-09-10 |  | 70% | 1.2mo | 89.71d |  | Carl Fourie [15%]; Wayne Naidoo | 736h | 515.2h |
| 4 | 1.3 | submit Apelon subcontract approval to CARDNO | 1h | 2012-05-23 A | 2012-05-23 A |  | 100% |  |  | start no earlier than 2012-05-23 | Jonnea Smith [50%]; Carl Fourie | 1h | 1h |
| 5 | 1.4 | draft Apelon subcontract | 4d | 2012-05-23 A | 2012-05-29 A | 4 | 100% |  |  |  | Rhonwyn Cornell [25%]; Jonnea Smith [50%]; Carl Fourie | 14.4h | 14.4h |
| 6 | 1.5 | Sign Apelon subcontract | 5d | 2012-05-29 A | 2012-06-05 A | 5 | 100% |  |  |  | Carl Fourie [1.7%]; Chris Seebregts [1.7%]; Jonnea Smith [1.7%] | 2h | 2h |
| 7 | 1.6 | Submit Sysnet subcontract approval to CARDNO | 1h | 2012-05-29 A | 2012-05-29 A |  | 100% |  |  | start no earlier than 2012-05-29 | Regenstrief Institute | 1h | 1h |
| 8 | 1.7 | Draft Sysnet/Regenstrief subcontract | 2d | 2012-05-29 A | 2012-05-31 A | 7 | 100% |  |  | start no earlier than 2012-05-18 | Regenstrief Institute | 16h | 16h |
| 9 | 1.8 | Sign Sysnet/Regenstrief subcontract | 5d | 2012-05-31 A | 2012-06-07 A | 8 | 100% |  |  |  | Regenstrief Institute [5%] | 2h | 2h |
| 10 | 1.9 | Secure NDC server space | 8w | 2012-05-22 A | 2012-07-16 |  | 40% | 4.8w | 129.71d |  | Richard Gakuba [75%] | 240h | 96h |
| 11 | 1.10 | Develop M&E plan | 3w | 2012-05-22 A | 2012-06-11 |  | 40% | 1.8w | 154.71d |  | Carl Fourie [6.7%]; Emmanuel Rugomboka [20%]; Wayne Naidoo [6.7%]; Rhonwyn Cornell [33.3%] | 80h | 32h |
| 12 | 1.11 | RHEA Sept Meeting | 4d | 2012-09-24 A | 2012-09-27 |  | 10% | 3.6d | 0d | must start on 2012-09-24 |  | 32h | 3.2h |
| 13 | 2 | **Terminology Service** | 104d? | 2012-05-22 A | 2012-10-12 |  | 50% | 52.02d? | 65.71d |  |  | 974h | 360.2h |
| 14 | 2.1 | **Technical Development** | 8.25d | 2012-05-22 A | 2012-06-01 |  | 81% | 1.6d | 14.75d |  |  | 79.6h | 57h |
| 15 | 2.1.1 | Web-UI Review | 1w | 2012-05-22 A | 2012-05-28 A |  | 100% |  |  |  | Hannes Venter [33%] | 13.2h | 13.2h |
| 16 | 2.1.2 | Developer Integration Testing | 1.65w | 2012-05-22 A | 2012-06-01 A |  | 100% |  |  |  | Hannes Venter [20%] | 13.2h | 13.2h |
| 17 | 2.1.3 | Load Code Sets (LOINC-RW) | 1w | 2012-05-22 A | 2012-05-28 |  | 60% | 0.4w | 18d |  |  | 40h | 24h |
| 18 | 2.1.4 | Develop Data Recovery and Backup Solution | 1w | 2012-05-22 A | 2012-05-28 |  | 50% | 0.5w | 18d |  | Hannes Venter [33%] | 13.2h | 6.6h |
| 19 | 2.2 | Identify server requirements | 1d | 2012-06-04 A | 2012-06-04 A |  | 100% |  |  | must start on 2012-06-04 |  | 8h | 8h |
| 20 | 2.3 | MoH system approval | 1d | 2012-06-22 | 2012-06-22 | 14 |  |  | 0d | must start on 2012-06-22 | Richard Gakuba; Emmanuel Rugomboka | 9.6h |  |
| 21 | 2.4 | **Deploy on TS Server** | 35.75d? | 2012-06-01 A | 2012-07-20 |  | 17% | 29.79d? | 0d |  |  | 48h | 8h |
| 22 | 2.4.1 | Deploy in Jembi EC2 | 1d? | 2012-06-01 A | 2012-06-04 A | 14 | 100% |  |  |  | Hannes Venter | 8h | 8h |
| 23 | 2.4.2 | Deploy in NDC | 1w | 2012-07-16 | 2012-07-20 | 20 |  |  | 0d | must start on 2012-07-16 | Hannes Venter [50%]; Ishimwe Ngezahayo [50%] | 40h |  |
| 24 | 2.5 | Documentation Sprint | 2w | 2012-06-01 A | 2012-06-15 A | 14 | 100% |  |  |  | Hannes Venter | 80h | 80h |
| 25 | 2.6 | Decide training and support plans | 2w | 2012-06-07 A | 2012-06-20 A |  | 100% |  |  | must start on 2012-06-07 | Rhonwyn Cornell [2%]; Apelon Inc [4%] | 4.8h | 4.8h |
| 26 | 2.7 | Training and support material developed | 3w | 2012-06-21 A | 2012-07-11 A | 25 | 100% |  |  | start no earlier than 2012-06-11 | Hannes Venter [5%]; Apelon Inc [15%] | 24h | 24h |
| 27 | 2.8 | Training | 1.12w | 2012-07-23 A | 2012-07-30 | 21 | 88% | 0.14w | 29.4d |  | Hannes Venter; Apelon Inc | 56h | 50.4h |
| 28 | 2.9 | Apelon technical support | 4mo | 2012-06-25 A | 2012-10-12 | 20 | 20% | 3.2mo | 65.71d |  | Apelon Inc | 640h | 128h |
| 29 | 2.10 | System evaluation | 1.5d | 2012-09-10 | 2012-09-11 | 27 |  |  | 0d | must start on 2012-09-10 | Rhonwyn Cornell; Wayne Naidoo | 24h |  |

Notes:
- 10: Waiting on the MoH contact to me signed
- 11: M&E was absent from the original project proposal. An M&E outline was presented to the MoH and RHEA Working Group 2 months ago and we are still awaiting feedback. Changing timelines are having a large impact on M&E options and timeframes. A realistic plan is currently being created. It is likely that M&E will be restricted to the technical aspects of the project.
- 12: Waiting for feedback from group around the objective and content of the meeting before we send out a formal invitation. A request for input has been sent to the RHEA working group on 3 occasions.
- 15: changes been made on request from MoH
- 17: MoH has identified additional code sets it would like added to the terminology service. MoH exploring how to access and load these code sets (with Jembi support for loading codes sets).
- 18: finalization will depend on the deployment environment
- 20: Waiting for data to be loaded onto the system and for it to be deployed on the final deployment servers
- 23: Still waiting for the deployment environment to be secured.
- 24: Underway and will be completed by mid next week, in time for the Terminology Service training
- 25: Training structure and content still being define, will be completed pre in country training. / Support plans identified but still being documented
- 26: Training materials are being tailored to the needs of the RHEA project. / The Apelon team are waiting for information about the trainees from the MoH in order to finalize the training content

| ID | WBS | Task | Duration | Start | Finish | Predecessors | Complete | Remaining | Total slack | Constraint | Resources | Work | Actual work |
| --- | --- | --- | --- | --- | --- | --- | --- | --- | --- | --- | --- | --- | --- |
| 30 | 3 | **Facility Registry** | 119d | 2012-05-22 A | 2012-11-02 |  | 38% | 73.2d | 50.71d |  |  | 961.6h | 255.52h |
| 31 | 3.1 | **Technical development** | 15d | 2012-06-05 A | 2012-06-25 |  | 90% | 1.5d | 0d |  |  | 120h | 108h |
| 32 | 3.1.1 | Testing and bug fixes | 3w | 2012-06-05 A | 2012-06-25 |  | 90% | 0.3w | 0d | must start on 2012-06-05 | InSTEDD | 120h | 108h |
| 33 | 3.2 | MoH system approval | 2d | 2012-06-26 A | 2012-06-27 | 31 | 60% | 0.8d | 142.71d |  | Richard Gakuba | 16h | 9.6h |
| 34 | 3.3 | Decide server requirements | 2d | 2012-05-22 A | 2012-05-23 A |  | 100% |  |  |  | Michel Makolo [50%]; InSTEDD [20%] | 11.2h | 11.2h |
| 35 | 3.4 | Support structure designed | 1w | 2012-06-08 A | 2012-06-14 |  | 60% | 0.4w | 0d | must start on 2012-06-08 | Rhonwyn Cornell [20%]; InSTEDD [20%] | 16h | 9.6h |
| 36 | 3.5 | Training and support plans decided | 0.6w | 2012-06-15 A | 2012-06-19 |  | 80% | 0.12w | 0d | must start on 2012-06-15 | InSTEDD [26.7%] | 6.4h | 5.12h |
| 37 | 3.6 | Training and support materials developed | 3w | 2012-06-20 A | 2012-07-10 | 36 | 70% | 0.9w | 133.71d |  | InSTEDD [20%] | 24h | 16.8h |
| 38 | 3.7 | Pre-training prep | 7w | 2012-06-25 A | 2012-08-10 |  | 85% | 1.05w | 0d | must start on 2012-06-25 | InSTEDD [40%] | 112h | 95.2h |
| 39 | 3.8 | Training | 1w | 2012-08-13 | 2012-08-17 | 38 |  |  | 0d | must start on 2012-08-13 | InSTEDD | 40h |  |
| 40 | 3.9 | deployment | 1w | 2012-07-23 | 2012-07-27 |  |  |  | 0d | must start on 2012-07-23 | InSTEDD | 40h |  |
| 41 | 3.10 | System support | 3.5mo | 2012-07-30 | 2012-11-02 | 40 |  |  | 50.71d |  | InSTEDD | 560h |  |
| 42 | 3.11 | Evaluation | 1w | 2012-09-17 | 2012-09-21 | 40 |  |  | 0d | must start on 2012-09-17 | Wayne Naidoo [20%]; Rhonwyn Cornell [20%] | 16h |  |
| 43 | 4 | **Client Registry** | 90d? | 2012-05-22 A | 2012-09-24 |  | 17% | 74.55d? | 79.71d |  |  | 1496h | 256h |
| 44 | 4.1 | Odysseas trip to Indy | 1d? | 2012-05-22 | 2012-05-22 |  |  |  | 38d |  |  | 8h |  |
| 45 | 4.2 | **Technical evaluation** | 53d | 2012-05-22 A | 2012-08-02 |  | 20% | 42.4d | 116.71d |  |  | 480h | 96h |
| 46 | 4.2.1 | OpenEMPI source code available | 1d | 2012-05-22 A | 2012-05-22 A |  | 100% |  |  | start no earlier than 2012-05-21 | Regenstrief Institute | 8h | 8h |
| 47 | 4.2.2 | Requirements specifications | 1.8w | 2012-07-16 | 2012-07-26 |  |  |  | 0d | must start on 2012-07-16 |  | 72h |  |
| 48 | 4.2.3 | Document Security Model for pilot | 2d | 2012-07-16 | 2012-07-17 | 44 |  |  | 0d | must start on 2012-07-16 |  | 16h |  |
| 49 | 4.2.4 | Document Actors/Actions | 2d | 2012-07-16 | 2012-07-17 | 44 |  |  | 0d | start no earlier than 2012-07-16 |  | 16h |  |
| 50 | 4.2.5 | Create sequence diagram | 1d | 2012-07-18 | 2012-07-18 | 49 |  |  | 0d | must start on 2012-07-18 |  | 8h |  |
| 51 | 4.2.6 | messaging filters | 2d | 2012-07-16 | 2012-07-17 | 44 |  |  | 0d | must start on 2012-07-16 |  | 16h |  |
| 52 | 4.2.7 | Document performance goals of transactions | 2d | 2012-07-16 | 2012-07-17 | 44 |  |  | 0d | must start on 2012-07-16 |  | 16h |  |
| 53 | 4.2.8 | Reporting requirements definition | 4d | 2012-07-16 | 2012-07-19 | 44 |  |  | 0d | must start on 2012-07-16 |  | 32h |  |
| 54 | 4.2.9 | Draft review | 2d | 2012-07-19 | 2012-07-20 |  |  |  | 0d | must start on 2012-07-19 |  | 16h |  |
| 55 | 4.2.10 | Update from review | 2d | 2012-07-23 | 2012-07-24 |  |  |  | 0d | must start on 2012-07-23 |  | 16h |  |
| 56 | 4.2.11 | Confirm compliance | 2d | 2012-07-25 | 2012-07-26 |  |  |  | 121.71d | start no earlier than 2012-07-25 |  | 16h |  |

Notes:
- 33: Acceptance policy has been sent to the MoH to agree. Once this is done Jembi, InSTEDD and the MoH can sign off on the current facility registry
- 35: Have requested from InSTEDD. They are reluctant to complete information as they see this as being dictated by the NDC
- 40: Waiting for the deployment environment to be secured. MoH is working on this.
- 43: Revised project plan pushed the delivery of the Client Registry out by 2.5 weeks. The revised project plan also comes with a warning that the team developing the Client Registry may not be able to achieve these targets

| ID | WBS | Task | Duration | Start | Finish | Predecessors | Complete | Remaining | Total slack | Constraint | Resources | Work | Actual work |
| --- | --- | --- | --- | --- | --- | --- | --- | --- | --- | --- | --- | --- | --- |
| 57 | 4.2.12 | **Review of data** | 24d | 2012-07-02 A | 2012-08-02 |  | 35% | 15.48d | 0d | start no earlier than 2012-05-22 |  | 248h | 88h |
| 58 | 4.2.12.1 | Access to production data - Ubudehe data | 1d | 2012-07-02 A | 2012-07-02 A |  | 100% |  |  | must start on 2012-07-02 |  | 8h | 8h |
| 59 | 4.2.12.2 | Remote access to production data - Ubedehe data | 1.8w | 2012-07-03 A | 2012-07-13 A | 58 | 100% |  |  | must start on 2012-07-03 |  | 72h | 72h |
| 60 | 4.2.12.3 | OpenMRS database | 1d | 2012-07-03 A | 2012-07-03 A | 58 | 100% |  |  | must start on 2012-07-03 |  | 8h | 8h |
| 61 | 4.2.12.4 | Data analysis | 1.8w | 2012-07-23 | 2012-08-02 |  |  |  | 0d | must start on 2012-07-23 |  | 72h |  |
| 62 | 4.2.12.5 | Identifing fields and candidated for matching | 1.2w | 2012-07-23 | 2012-07-30 | 54 |  |  | 0d | must start on 2012-07-23 |  | 48h |  |
| 63 | 4.2.12.6 | Map data between OpenMRS and Ubudehe | 2d | 2012-07-31 | 2012-08-01 | 62 |  |  | 0d | must start on 2012-07-31 |  | 16h |  |
| 64 | 4.2.12.7 | Recommend what fields to use | 1d | 2012-07-31 | 2012-07-31 | 62 |  |  | 0d | must start on 2012-07-31 |  | 8h |  |
| 65 | 4.2.12.8 | Finalize data elements for clients | 2d | 2012-08-01 | 2012-08-02 | 64 |  |  | 0d | must start on 2012-08-01 |  | 16h |  |
| 66 | 4.3 | **Technical Development** | 73d? | 2012-05-22 A | 2012-08-30 |  | 21% | 57.44d? | 0d |  |  | 368h | 44h |
| 67 | 4.3.1 | Install software in development environment (JHSR Office) | 1mo | 2012-05-22 A | 2012-06-18 |  | 50% | 0.5mo | 0d | must start on 2012-05-22 | Sysnet [25%] | 40h | 20h |
| 68 | 4.3.2 | Define identifier domains | 1d? | 2012-05-22 A | 2012-05-22 A | 44 | 100% |  |  | must start on 2012-07-16 | Sysnet | 8h | 8h |
| 69 | 4.3.3 | EC2 Dev Server Instance | 1d? | 2012-05-22 A | 2012-05-22 A |  | 100% |  |  | must start on 2012-05-22 | Sysnet | 8h | 8h |
| 70 | 4.3.4 | EC2 configuration | 1d? | 2012-07-17 A | 2012-07-17 A | 69 | 100% |  |  | must start on 2012-07-17 | Sysnet | 8h | 8h |
| 71 | 4.3.5 | Modify OpenEMPI data model | 1w? | 2012-08-03 | 2012-08-09 | 61 |  |  | 0d | must start on 2012-08-03 |  | 40h |  |
| 72 | 4.3.6 | Modify OpenEMPI data loader | 1w? | 2012-08-10 | 2012-08-16 | 71 |  |  | 0d | must start on 2012-08-10 |  | 40h |  |
| 73 | 4.3.7 | Software Release 1 - Data model & Loader changes | 1d? | 2012-08-17 | 2012-08-17 | 72 |  |  | 0d | must start on 2012-08-17 |  | 8h |  |
| 74 | 4.3.8 | Software Release 2 - Matching Algorithm Enhancements | 2w? | 2012-08-17 | 2012-08-30 | 81 |  |  | 0d | must start on 2012-08-17 |  | 80h |  |
| 75 | 4.3.9 | Software Release 3 Performance tuning enhancements | 1w? | 2012-08-24 | 2012-08-30 | 87 |  |  | 0d | must start on 2012-08-24 |  | 40h |  |
| 76 | 4.3.10 | Staging server access | 1d | 2012-08-06 | 2012-08-06 |  |  |  | 0d | must start on 2012-08-06 |  | 8h |  |
| 77 | 4.3.11 | Staging server instillation | 2d | 2012-08-07 | 2012-08-08 | 76 |  |  | 0d | must start on 2012-08-07 |  | 16h |  |
| 78 | 4.3.12 | Staging server configuration | 2d | 2012-08-09 | 2012-08-10 | 77 |  |  | 0d | must start on 2012-08-09 |  | 16h |  |
| 79 | 4.3.13 | Data load | 2d | 2012-08-13 | 2012-08-14 | 78 |  |  | 0d | must start on 2012-08-13 |  | 16h |  |
| 80 | 4.3.14 | Report development | 1w | 2012-07-20 | 2012-07-26 | 53 |  |  | 0d | must start on 2012-07-20 |  | 40h |  |

| ID | WBS | Task | Duration | Start | Finish | Predecessors | Complete | Remaining | Total slack | Constraint | Resources | Work | Actual work |
| --- | --- | --- | --- | --- | --- | --- | --- | --- | --- | --- | --- | --- | --- |
| 81 | 4.4 | **Defining the algorithm** | 10d? | 2012-08-03 | 2012-08-16 |  |  |  | 0d | must start on 2012-08-03 |  | 72h |  |
| 82 | 4.4.1 | Parameterize algorithm | 2d? | 2012-08-03 | 2012-08-06 | 61 |  |  | 0d | must start on 2012-08-03 |  | 16h |  |
| 83 | 4.4.2 | Validate algorithm | 1d? | 2012-08-07 | 2012-08-07 | 82 |  |  | 1d |  |  | 8h |  |
| 84 | 4.4.3 | Review results | 2d? | 2012-08-09 | 2012-08-10 | 83 |  |  | 0d | must start on 2012-08-09 |  | 16h |  |
| 85 | 4.4.4 | Accept algorithm | 2d? | 2012-08-13 | 2012-08-14 | 84 |  |  | 0d | must start on 2012-08-13 |  | 16h |  |
| 86 | 4.4.5 | Development modifications | 2d? | 2012-08-15 | 2012-08-16 | 85 |  |  | 0d | must start on 2012-08-15 |  | 16h |  |
| 87 | 4.5 | **Performance Testing of OpenEMPI** | 20d? | 2012-07-27 | 2012-08-23 |  |  |  | 0d | must start on 2012-07-27 |  | 64h |  |
| 88 | 4.5.1 | Define testing transactions | 4d? | 2012-07-27 | 2012-08-01 |  |  |  | 0d | must start on 2012-07-27 |  | 32h |  |
| 89 | 4.5.2 | Run test | 2d? | 2012-08-20 | 2012-08-21 | 88 |  |  | 0d | must start on 2012-08-20 |  | 16h |  |
| 90 | 4.5.3 | Review results | 2d? | 2012-08-22 | 2012-08-23 | 89 |  |  | 0d | must start on 2012-08-22 |  | 16h |  |
| 91 | 4.6 | **Deployment activities** | 84d? | 2012-05-22 A | 2012-09-14 |  | 35% | 54.6d? | 0d |  |  | 240h | 84h |
| 92 | 4.6.1 | Production server access | 1w? | 2012-07-13 A | 2012-07-19 A |  | 100% |  |  | must start on 2012-08-06 | MoH OpenMRS team | 40h | 40h |
| 93 | 4.6.2 | Production installation | 1w? | 2012-08-13 A | 2012-08-17 A | 92 | 100% |  |  | start no earlier than 2012-08-13 | Sysnet | 40h | 40h |
| 94 | 4.6.3 | Production configuration | 5d | 2012-05-22 A | 2012-08-24 | 93 | 10% | 4.5d | 0d | must start on 2012-08-20 | Sysnet [50%]; Regenstrief Institute [50%] | 40h | 4h |
| 95 | 4.6.4 | Load data from Ubedehe | 3d | 2012-08-27 | 2012-08-29 | 94 |  |  | 0d | must start on 2012-08-27 | Sysnet [50%]; Regenstrief Institute [50%] | 24h |  |
| 96 | 4.6.5 | Load OpenMRS data | 3d | 2012-08-30 | 2012-09-03 | 95 |  |  | 0d | must start on 2012-08-30 | Sysnet [50%]; Regenstrief Institute [50%] | 24h |  |
| 97 | 4.6.6 | Functional testing | 3d | 2012-09-04 | 2012-09-06 | 96 |  |  | 0d | must start on 2012-09-04 |  | 24h |  |
| 98 | 4.6.7 | Performance testing | 3d | 2012-09-07 | 2012-09-11 | 97 |  |  | 0d | must start on 2012-09-07 |  | 24h |  |
| 99 | 4.6.8 | Intergration testing | 3d | 2012-09-12 | 2012-09-14 | 98 |  |  | 0d | must start on 2012-09-12 |  | 24h |  |
| 100 | 4.7 | MoH system approval | 1d? | 2012-09-17 | 2012-09-17 | 99 |  |  | 0d | must start on 2012-09-17 | Richard Gakuba | 8h |  |
| 101 | 4.8 | **Training and Support** | 54d? | 2012-06-19 A | 2012-08-31 |  | 5% | 51.52d? | 0d |  |  | 216h | 32h |
| 102 | 4.8.1 | Define support requirements | 2.5d? | 2012-06-19 A | 2012-06-21 | 67 | 80% | 0.5d? | 0d | must start on 2012-05-22 | Michel Makolo; Regenstrief Institute | 40h | 32h |
| 103 | 4.8.2 | Develop training and support material | 1.75mo | 2012-07-16 | 2012-08-31 | 69, 102 |  |  | 0d | must start on 2012-07-16 | Regenstrief Institute [21.4%]; Sysnet [21.4%] | 120h |  |
| 104 | 4.8.3 | Virtual training | 1d | 2012-08-30 | 2012-08-30 |  |  |  | 0d | must start on 2012-08-30 | Sysnet; Regenstrief Institute | 16h |  |
| 105 | 4.8.4 | On-site training | 1w | 2012-08-27 | 2012-08-31 |  |  |  | 0d | must start on 2012-08-27 |  | 40h |  |
| 106 | 4.9 | Evaluation | 1w | 2012-09-18 | 2012-09-24 | 91 |  |  | 0d | must start on 2012-09-18 | Rhonwyn Cornell [33.3%]; Wayne Naidoo [33.3%]; Emmanuel Rugomboka [33.3%] | 40h |  |

Notes:
- 92: deployment environment not yet secured. MoH are working on this.
- 105: Availability for staff over this period is uncertain and it is possible that on-site training will change to virtual training with the support of Jembi staff on site in Rwanda.

| ID | WBS | Task | Duration | Start | Finish | Predecessors | Complete | Remaining | Total slack | Constraint | Resources | Work | Actual work |
| --- | --- | --- | --- | --- | --- | --- | --- | --- | --- | --- | --- | --- | --- |
| 107 | 5 | **Provider Registry** | 99d? | 2012-05-22 A | 2012-10-05 |  | 45% | 54.81d? | 70.71d |  |  | 1760.53h | 770.13h |
| 108 | 5.1 | **Technical development** | 44d? | 2012-05-22 A | 2012-07-20 |  | 60% | 17.64d? | 0d |  |  | 1176.53h | 696.53h |
| 109 | 5.1.1 | **Software Platform Determined** | 9d | 2012-05-22 A | 2012-06-01 A |  | 100% |  |  |  |  | 48h | 48h |
| 110 | 5.1.1.1 | Review and Evaluation | 8d | 2012-05-22 A | 2012-05-31 A |  | 100% |  |  |  | Intrahealth [62.5%] | 40h | 40h |
| 111 | 5.1.1.2 | Recommendation made with justification | 1d | 2012-06-01 A | 2012-06-01 A | 110 | 100% |  |  |  | Intrahealth | 8h | 8h |
| 112 | 5.1.2 | **Public Registry (PR) specifications and customizations document** | 4.67d? | 2012-06-04 A | 2012-06-08 A | 109 | 100% |  |  |  |  | 48.53h | 48.53h |
| 113 | 5.1.2.1 | Draft | 4d | 2012-06-04 A | 2012-06-07 A |  | 100% |  |  |  | Intrahealth | 32h | 32h |
| 114 | 5.1.2.2 | Review | 5.33h | 2012-06-08 A | 2012-06-08 A | 113 | 100% |  |  |  | Ryan Crichton [70%]; Wayne Naidoo; Intrahealth | 8.53h | 8.53h |
| 115 | 5.1.2.3 | Finalise | 1d? | 2012-06-04 A | 2012-06-04 A |  | 100% |  |  |  | Intrahealth | 8h | 8h |
| 116 | 5.1.3 | **Collect Provider Registry data sources from iHRIS and Liz/RapidSMS (possibly OpenMRS)** | 25d | 2012-06-04 A | 2012-07-06 A |  | 100% |  |  |  |  | 600h | 600h |
| 117 | 5.1.3.1 | iHRIS | 5w | 2012-06-04 A | 2012-07-06 A |  | 100% |  |  | must start on 2012-06-04 |  | 200h | 200h |
| 118 | 5.1.3.2 | CHW RapidSMS | 5w | 2012-06-04 A | 2012-07-06 A |  | 100% |  |  | must start on 2012-06-04 |  | 200h | 200h |
| 119 | 5.1.3.3 | OpenMRS | 5w | 2012-06-04 A | 2012-07-06 A |  | 100% |  |  | must start on 2012-06-04 |  | 200h | 200h |
| 120 | 5.1.4 | Implementing customizations to PR UI | 6w | 2012-06-11 | 2012-07-20 | 112 |  |  | 0d | must start on 2012-06-11 | Intrahealth | 240h |  |
| 121 | 5.1.5 | Implementing customisations to PR Web Services | 6w | 2012-06-11 | 2012-07-20 |  |  |  | 0d | must start on 2012-06-11 | Intrahealth | 240h |  |
| 122 | 5.2 | MoH system approval | 1w | 2012-07-30 | 2012-08-03 | 121, 120 |  |  | 0d | must start on 2012-07-30 | Richard Gakuba | 40h |  |
| 123 | 5.3 | Decide server requirements | 1w | 2012-06-04 A | 2012-06-08 | 109 | 40% | 0.6w | 155.71d |  | Intrahealth [20%]; Michel Makolo [20%] | 16h | 6.4h |
| 124 | 5.4 | Document support requirements | 3w | 2012-05-22 A | 2012-06-11 |  | 80% | 0.6w | 154.71d |  | Intrahealth [20%] | 24h | 19.2h |
| 125 | 5.5 | Develop training and support plans | 1w | 2012-06-13 A | 2012-06-19 A | 124, 109 | 100% |  |  | must start on 2012-06-13 | Intrahealth [60%] | 24h | 24h |
| 126 | 5.6 | Develop trainng and support material | 4w | 2012-07-09 | 2012-08-03 | 125 |  |  | 0d | must start on 2012-07-09 | Intrahealth | 160h |  |
| 127 | 5.7 | **Training** | 48d | 2012-06-13 A | 2012-08-17 |  | 50% | 24d | 0d |  |  | 64h | 24h |
| 128 | 5.7.1 | Schedule training | 1w | 2012-06-13 A | 2012-06-19 A |  | 100% |  |  | must start on 2012-06-13 | Rhonwyn Cornell [30%]; Intrahealth [30%] | 24h | 24h |
| 129 | 5.7.2 | Training | 1w | 2012-08-13 | 2012-08-17 | 126, 128 |  |  | 0d | must start on 2012-08-13 | Intrahealth | 40h |  |
| 130 | 5.8 | Evaluation | 1w | 2012-09-17 | 2012-09-21 | 127 |  |  | 0d | must start on 2012-09-17 | Wayne Naidoo [20%]; Rhonwyn Cornell [20%] | 16h |  |
| 131 | 5.9 | System support | 8w | 2012-08-13 | 2012-10-05 |  |  |  | 0d | must start on 2012-08-13 | Intrahealth [75%] | 240h |  |

Notes:
- 108: Latest update from Intrahealth is that the Provider Registry is on track for delivery at the end of the week
- 123: Awaiting information from Intrahealth
- 124: The support requirements have been identified but are still being documented

| ID | WBS | Task | Duration | Start | Finish | Predecessors | Complete | Remaining | Total slack | Free slack | Constraint | Resources | Work | Actual work |
| --- | --- | --- | --- | --- | --- | --- | --- | --- | --- | --- | --- | --- | --- | --- |
| 132 | 6 | **OpenMRS** | 136d? | 2012-05-22 A | 2012-11-27 |  | 53% | 64.48d? | 33.71d |  |  |  | 1488h | 378.4h |
| 133 | 6.1 | **Technical development** | 97d? | 2012-05-22 A | 2012-10-03 |  | 66% | 32.77d? | 72.21d | 0d |  |  | 456h | 139.2h |
| 134 | 6.1.1 | Update OMRS Concept with Maternal Data Mappings | 12w | 2012-05-22 A | 2012-08-13 |  | 90% | 1.2w | 109.22d | 0d |  | MoH OpenMRS team [1.7%]; Desire Ruzigana [1.7%] | 16h | 14.4h |
| 135 | 6.1.2 | Update HTML Form Implementations and Link them with Final Maternal Data Mappings | 11w | 2012-05-29 A | 2012-08-21 | 134 | 90% | 1.1w | 103.72d |  |  | Desire Ruzigana [1.8%]; Wayne Naidoo [1.8%] | 16h | 14.4h |
| 136 | 6.1.3 | Rwandan Primary Care and RHEA API Integration Design | 6w | 2012-06-05 A | 2012-07-16 A | 135 | 100% |  |  |  |  | Desire Ruzigana [16.7%] | 40h | 40h |
| 137 | 6.1.4 | Development - Rwandan Primary Care + RHEA API Integration | 11w | 2012-06-19 A | 2012-09-03 | 136 | 60% | 4.4w | 22d | 0d |  | Desire Ruzigana [9.1%] | 40h | 24h |
| 138 | 6.1.5 | Maternal Summary Development | 3w | 2012-06-25 A | 2012-07-13 |  | 90% | 0.3w | 130.22d | 0d |  | Wayne Naidoo [6.7%] | 8h | 7.2h |
| 139 | 6.1.6 | Integration Testing | 11w | 2012-07-03 A | 2012-10-03 | 137 | 60% | 4.4w | -38d | 0d |  | MoH OpenMRS team [4.5%]; Desire Ruzigana [4.5%] | 40h | 24h |
| 140 | 6.1.7 | Update Design Documentation | 1w | 2012-07-16 A | 2012-07-20 | 138 | 20% | 0.8w | 125.21d |  |  | Wayne Naidoo [40%] | 16h | 3.2h |
| 141 | 6.1.8 | Develop User Documentation | 4w | 2012-07-03 A | 2012-09-25 | 138, 137 | 20% | 3.2w | 78.21d |  |  | Wayne Naidoo [25%] | 40h | 8h |
| 142 | 6.1.9 | RHEA Team Testing and Iteration | 2w | 2012-08-13 | 2012-08-24 | 139 |  |  | -38d | 0d | must start on 2012-08-13 | Ryan Crichton [16.7%]; Wayne Naidoo [16.7%]; Desire Ruzigana [16.7%] | 40h |  |
| 143 | 6.1.10 | development of script for uploading Ubudehe data at health centres | 3w? | 2012-08-08 | 2012-08-28 |  |  |  | -17d | 0d | start no earlier than 2012-08-08 |  | 120h |  |
| 144 | 6.1.11 | integration of the appointment module | 2w? | 2012-08-01 A | 2012-08-14 |  | 5% | 1.9w? | 108.21d |  | start no earlier than 2012-08-01 |  | 80h | 4h |
| 145 | 6.2 | MoH system approval | 4h? | 2012-10-04 | 2012-10-04 | 133 |  |  | 72.21d |  |  | Emmanuel Rugomboka; Richard Gakuba | 8h |  |
| 146 | 6.3 | Pre-rollout clinic site assessments | 2w | 2012-05-22 A | 2012-06-04 A |  | 100% |  |  |  |  | Michel Makolo [40%] | 32h | 32h |
| 147 | 6.4 | Develop training and support plan | 1w | 2012-06-05 A | 2012-06-11 | 146 | 80% | 0.2w | 144.71d | 0d | start no earlier than 2012-07-25 | Michel Makolo [8%]; Liz Peloso [8%]; Emmanuel Rugomboka [8%]; MoH OpenMRS team [8%]; Rhonwyn Cornell [8%] | 16h | 12.8h |
| 148 | 6.5 | Develop training material | 2w? | 2012-06-11 | 2012-06-25 | 147 |  |  | 144.71d |  |  |  | 80h |  |
| 149 | 6.6 | Site infrustructure and hardware rollout | 1mo | 2012-06-05 A | 2012-07-02 | 146 | 70% | 0.3mo | 139.71d |  |  | MoH OpenMRS team [75%] | 120h | 84h |
| 150 | 6.7 | **Deployment** | 65d? | 2012-07-18 A | 2012-10-16 |  | 6% | 60.92d? | 33.71d | 0d |  |  | 344h | 20.8h |
| 151 | 6.7.1 | ANC clinic computers | 3.2w? | 2012-07-18 A | 2012-08-08 |  | 20% | 2.56w? | 0d |  | must start on 2012-07-18 |  | 104h | 20.8h |
| 152 | 6.7.2 | Uploading of Ubhuthe database info on site | 3w? | 2012-08-29 | 2012-09-18 | 143 |  |  | -17d | 0d |  | MoH OpenMRS team | 120h |  |
| 153 | 6.7.3 | Deploy ANC OpenMRS module | 1mo | 2012-09-19 | 2012-10-16 | 152 |  |  | 33.71d |  | start no earlier than 2012-08-27 |  | 120h |  |
| 154 | 6.8 | **Training** | 69d? | 2012-06-26 A | 2012-09-28 |  | 45% | 38.01d? | 0d |  |  |  | 232h | 89.6h |
| 155 | 6.8.1 | IT skills training | 1.6mo? | 2012-06-26 A | 2012-08-08 |  | 80% | 0.32mo? | 0d |  | must start on 2012-06-28 | MoH OpenMRS team [21.9%]; Liz Peloso [21.9%] | 112h | 89.6h |
| 156 | 6.8.2 | Application training | 5w | 2012-08-27 | 2012-09-28 | 152 |  |  | -17d | 0d | must start on 2012-08-27 | MoH OpenMRS team [30%]; Liz Peloso [30%] | 120h |  |
| 157 | 6.9 | System support | 6w | 2012-10-17 | 2012-11-27 | 150 |  |  | 33.71d |  |  | MoH OpenMRS team [26.7%]; Desire Ruzigana [26.7%]; Wayne Naidoo [13.3%] | 160h |  |
| 158 | 6.10 | Evaluation | 2w | 2012-10-01 | 2012-10-12 | 156 |  |  | 65.71d |  | start no earlier than 2012-09-10 | Rhonwyn Cornell [16.7%]; Emmanuel Rugomboka [16.7%]; Wayne Naidoo [16.7%] | 40h |  |

Notes:
- 137: Recommendation which requires change was made and approved last week. This is part of testing and development for the next 2 weeks.
- 138: awaiting final updated document
- 140: system still being developed which is current focus.
- 147: Training schedule and plan for the OpenMRS training is still being finalized
- 149: Being carried out by the MoH. Site assessments showed that the majority of sites have the required infrastructure
- 151: Computers are being distributed as the IT skills training is being rolled out.
- 156: training plan is still being finalized.

| ID | WBS | Task | Duration | Start | Finish | Predecessors | Complete | Remaining | Total slack | Free slack | Constraint | Resources | Work | Actual work |
| --- | --- | --- | --- | --- | --- | --- | --- | --- | --- | --- | --- | --- | --- | --- |
| 159 | 7 | **RapidSMS** | 20d? | 2012-08-06 | 2012-08-31 |  |  |  | 0d |  |  |  | 8h |  |
| 160 | 7.1 | System testing and bug fixing | 1mo? | 2012-08-06 | 2012-08-31 |  |  |  | 0d |  | must start on 2012-08-06 |  | 8h |  |
| 161 | 8 | **Shared Health Record** | 96.5d? | 2012-05-22 A | 2012-10-03 |  | 50% | 48.39d? | 73.21d |  |  |  | 800h | 80h |
| 162 | 8.1 | **Technical development** | 94d | 2012-05-22 A | 2012-09-28 |  | 67% | 30.83d | 75.71d |  |  |  | 248h | 70.4h |
| 163 | 8.1.1 | API Development | 9w | 2012-05-22 A | 2012-07-23 |  | 80% | 1.8w | 123.71d | 0d |  |  | 16h | 12.8h |
| 164 | 8.1.2 | Developer Unit + Integtration Testing and Code Reviews | 10w | 2012-05-24 A | 2012-08-06 | 163 | 80% | 2w | 114.71d |  |  |  | 40h | 32h |
| 165 | 8.1.3 | Develop Load and Performance Testing Plan | 1w | 2012-07-16 A | 2012-07-20 |  | 80% | 0.2w | 39.6d | 0d |  |  | 16h | 12.8h |
| 166 | 8.1.4 | Develop Backup and Redudancy Strategy | 1w | 2012-07-23 A | 2012-07-27 | 165 | 80% | 0.2w | 35d |  |  |  | 16h | 12.8h |
| 167 | 8.1.5 | Load and Performance Testing | 2w | 2012-09-17 | 2012-09-28 | 166, 165 |  |  | 0d |  | must start on 2012-09-17 |  | 80h |  |
| 168 | 8.1.6 | RHEA Team System Testing + Iteration | 2w | 2012-08-20 | 2012-08-31 |  |  |  | 0d |  | must start on 2012-08-20 |  | 80h |  |
| 169 | 8.2 | MoH system approval | 2d | 2012-09-03 | 2012-09-04 | 168 |  |  | 93.71d |  |  |  | 16h |  |
| 170 | 8.3 | Deployment | 1w | 2012-09-03 | 2012-09-07 | 168 |  |  | 90.71d |  |  |  | 24h |  |
| 171 | 8.4 | Decide server requirements | 1d | 2012-05-22 A | 2012-05-22 A |  | 100% |  |  |  |  |  | 8h | 8h |
| 172 | 8.5 | Develop training and support plan | 5d | 2012-07-23 A | 2012-07-27 |  | 10% | 4.5d | 10d | 0d | start no earlier than 2012-06-05 | Wayne Naidoo [20%]; Rhonwyn Cornell [20%] | 16h | 1.6h |
| 173 | 8.6 | Develop training and support material | 1w | 2012-07-30 | 2012-08-03 | 172 |  |  | 10d |  |  | Wayne Naidoo; Suranga Kasthurirathne | 80h |  |
| 174 | 8.7 | Training | 1w | 2012-08-20 | 2012-08-24 | 173 |  |  | 0d |  | must start on 2012-08-20 | Suranga Kasthurirathne [50%]; Wayne Naidoo [50%] | 40h |  |
| 175 | 8.8 | System support | 1.12mo | 2012-09-03 | 2012-10-03 | 168 |  |  | 73.21d |  |  | Suranga Kasthurirathne; Wayne Naidoo | 360h |  |
| 176 | 8.9 | Evaluation | 1d? | 2012-05-22 | 2012-05-22 |  |  |  | 168.71d |  |  |  | 8h |  |
| 177 | 9 | **Interoperability layer** | 169.71d | 2012-05-22 A | 2013-01-14 |  | 33% | 113.29d | 0d |  |  |  | 932.8h | 193.4h |
| 178 | 9.1 | **Technical development** | 51d | 2012-05-22 A | 2012-07-31 |  | 81% | 9.45d | 0d |  |  |  | 184.8h | 147h |
| 179 | 9.1.1 | Develop Transaction Overview Page | 1w | 2012-05-22 A | 2012-05-28 A |  | 100% |  |  |  |  | Ryan Crichton [42%] | 16.8h | 16.8h |
| 180 | 9.1.2 | Develop Transaction View page | 1w | 2012-05-29 A | 2012-06-04 A | 179 | 100% |  |  |  |  | Ryan Crichton [42%] | 16.8h | 16.8h |
| 181 | 9.1.3 | Develop Monitoring page | 1w | 2012-06-05 A | 2012-06-11 A | 180 | 100% |  |  |  |  | Ryan Crichton [42%] | 16.8h | 16.8h |
| 182 | 9.1.4 | Develop Login functionality | 1w | 2012-06-12 A | 2012-06-18 A | 181 | 100% |  |  |  |  | Ryan Crichton [42%] | 16.8h | 16.8h |
| 183 | 9.1.5 | Develop Transaction Edit page | 1w | 2012-06-19 A | 2012-06-25 A | 182 | 100% |  |  |  |  | Ryan Crichton [42%] | 16.8h | 16.8h |
| 184 | 9.1.6 | Develop Audit Log functionality | 1w | 2012-06-26 A | 2012-07-02 A | 183 | 100% |  |  |  |  | Ryan Crichton [42%] | 16.8h | 16.8h |
| 185 | 9.1.7 | System Testing and bug fixes | 1.05mo | 2012-07-03 A | 2012-07-31 | 179, 180, 181, 183, 184, 182 | 55% | 0.47mo | 0d |  | must finish on 2012-07-31 | Ryan Crichton [50%] | 84h | 46.2h |
| 186 | 9.2 | User Documentation Sprint | 2w | 2012-08-01 A | 2012-08-14 | 178 | 20% | 1.6w | 13d |  |  | Ryan Crichton [15%] | 12h | 2.4h |
| 187 | 9.3 | Technical Documentation Sprint | 2w | 2012-07-17 A | 2012-07-30 |  | 60% | 0.8w | 24d |  |  | Ryan Crichton [15%] | 12h | 7.2h |
| 188 | 9.4 | Implement Orchestrations for developed components | 2.2mo | 2012-07-17 A | 2012-09-14 | 185 | 40% | 1.32mo | 0d |  | must finish on 2012-09-14 | Ryan Crichton [3.4%] | 12h | 4.8h |
| 189 | 9.5 | MoH system approval | 1d | 2012-08-01 | 2012-08-01 | 178 |  |  | 22d |  |  | Richard Gakuba | 8h |  |
| 190 | 9.6 | Deploy system | 1.14w | 2012-09-17 | 2012-09-24 | 189, 188 |  |  | 77.5d | 0d |  | Ryan Crichton [70%] | 32h |  |
| 191 | 9.7 | Identify server requirements | 1.43d | 2012-05-22 A | 2012-05-23 A |  | 100% |  |  |  |  | Ryan Crichton [70%] | 8h | 8h |
| 192 | 9.8 | Develop training and support plans | 2w | 2012-06-18 A | 2012-06-29 A |  | 100% |  |  |  | must start on 2012-06-18 | Ryan Crichton [30%] | 24h | 24h |
| 193 | 9.9 | Develop training and support material | 2w | 2012-08-13 | 2012-08-24 | 192 |  |  | 100.71d |  | start no earlier than 2012-08-13 |  | 80h |  |
| 194 | 9.10 | Training | 1w | 2012-09-03 | 2012-09-07 | 186, 187, 189 |  |  | 0d |  | must start on 2012-09-03 | Ryan Crichton | 40h |  |
| 195 | 9.11 | System support | 4.29mo | 2012-09-17 | 2013-01-14 | 188 |  |  | 0d |  |  | Ryan Crichton [70%] | 480h |  |
| 196 | 9.12 | Evaluation | 2.5d | 2012-09-24 | 2012-09-27 | 190 |  |  | 77.5d |  |  | Wayne Naidoo; Rhonwyn Cornell | 40h |  |

Notes:
- 159: On track. Project plan will be update later this week.
- 163: outstanding 20% is related to developing the CDSS in the SHR. We are wait for rules definitions from Liz Peloso
- 165: Now that we know the deployment environment this should be completed this week
- 166: Now that we know the deployment environment this should be completed this week
- 167: can only do this once all registries are running in deployment environment
- 170: deployment environment not available. MoH are working on securing a server.
- 172: more detailed plan being developed. training not set until the end of Aug
- 173: training not set until the end of Aug
- 183: not on the critical path. Will happened in the next 2 weeks
- 184: not on the critical path and will happen in the next 2 weeks
- 185: Some delays in testing resulting from delays in deliver of other RHEA components.
- 192: currently underway not needed until the end of July
